# GD-09 - dakopbouw+binnenspouw

Schedule from MS Project, 2003-01-12 to 2003-02-05, status date 2003-01-08.
BAM Nelissen Van Egteren

## Calendars

- ALLEEN WERKDAGEN: Mon-Fri 08:30-12:30, 13:00-17:00; Sat-Sun off. Exceptions (off unless hours are given): 2003-01-11 to 2003-01-12 08:30-12:30, 13:00-17:00, 2003-01-18 to 2003-01-19 08:30-12:30, 13:00-17:00, 2003-01-25 to 2003-01-26 08:30-12:30, 13:00-17:00, 2003-02-01 to 2003-02-02 08:30-12:30, 13:00-17:00.

## Schedule

| ID | WBS | Task | Type | Duration | Start | Finish | Predecessors | Total slack | Free slack |
| --- | --- | --- | --- | --- | --- | --- | --- | --- | --- |
| 1 | 1 | **GEVEL/DAK FASE** |  | 25d | 2003-01-12 | 2003-02-05 |  | 0d |  |
| 2 | 1.1 | gevelkozijnen stellen |  | 5d | 2003-01-12 | 2003-01-16 |  | 10d | 0d |
| 3 | 1.2 | borstwering binnen metselen |  | 5d | 2003-01-14 | 2003-01-18 | 2SS+2d | 10d | 0d |
| 4 | 1.3 | metselen buitenspouwblad |  | 5d | 2003-01-17 | 2003-01-21 | 3SS+3d | 10d | 0d |
| 5 | 1.4 | gevelkozijnen waterdicht |  | 5d | 2003-01-22 | 2003-01-26 | 4SS+5d | 10d |  |
| 6 | 1.5 | dakranden+dakopstortingen |  | 5d | 2003-01-12 | 2003-01-16 |  | 0d |  |
| 7 | 1.6 | dakopbouw staalconstructie |  | 5d | 2003-01-17 | 2003-01-21 | 6SS+5d | 0d |  |
| 8 | 1.7 | dakopbouw gevelbeplating |  | 5d | 2003-01-22 | 2003-01-26 | 7SS+5d | 0d |  |
| 9 | 1.8 | dakopbouw dakbeplating |  | 5d | 2003-01-22 | 2003-01-26 | 8SS | 0d |  |
| 10 | 1.9 | dak isolatieplaten aanbrengen |  | 5d | 2003-01-27 | 2003-01-31 | 9SS+5d | 0d |  |
| 11 | 1.10 | dak dakbedekking aanbrengen |  | 5d | 2003-02-01 | 2003-02-05 | 10SS+5d | 0d |  |
| 12 | 1.11 | start afbouw fase | milestone | 0d | 2003-02-05 | 2003-02-05 | 11SS+5d | 0d |  |
